# House Build - House A

How a schedule from MS Project changed from version to version. A marks actual dates.

## Version 1 (saved 2013-05-31, file ssi-project2013advanced-example-01.mpp)

| ID | WBS | Task | Duration | Start | Finish | Predecessors | Total float |
| --- | --- | --- | --- | --- | --- | --- | --- |
| 1 | 1 | **Site** | 6d | 2013-05-30 | 2013-06-06 |  | 0d |
| 2 |  | Clear site | 4d | 2013-05-30 | 2013-06-04 |  | 0d |
| 3 |  | Set out | 2d | 2013-06-05 | 2013-06-06 | 2 | 0d |
| 4 | 2 | **Base** | 24d | 2013-06-07 | 2013-07-10 | 1 | 0d |
| 5 |  | Trenches | 3d | 2013-06-07 | 2013-06-11 |  | 0d |
| 6 |  | Footings | 5d | 2013-06-12 | 2013-06-18 | 5 | 0d |
| 7 |  | Concrete | 6d | 2013-06-19 | 2013-06-26 | 6 | 0d |
| 8 |  | Base brickwork | 6d | 2013-06-27 | 2013-07-04 | 7 | 0d |
| 9 |  | Plumbing and services | 4d | 2013-07-05 | 2013-07-10 | 8 | 81d |
| 10 | 3 | **Frame** | 47d | 2013-07-08 | 2013-09-10 |  | 0d |
| 11 |  | Floor | 10d | 2013-07-08 | 2013-07-19 | 8FS+1d | 74d |
| 12 |  | Frame | 26d | 2013-07-08 | 2013-08-12 | 8FS+1d | 0d |
| 13 |  | Structural steel | 10d | 2013-08-14 | 2013-08-27 | 8, 12FS+1d | 0d |
| 14 |  | Trussing | 10d | 2013-08-28 | 2013-09-10 | 12, 13 | 12d |
| 15 | 4 | **Lockup** | 51d | 2013-08-28 | 2013-11-06 |  | 0d |
| 16 |  | Window and door frames | 10d | 2013-08-28 | 2013-09-10 | 12, 13 | 0d |
| 17 |  | Brickwork | 9d | 2013-09-16 | 2013-09-26 | 16FS+3d | 0d |
| 18 |  | Roof structure and tile | 14d | 2013-09-27 | 2013-10-16 | 17, 14 | 0d |
| 19 |  | Fix rainwater goods | 3d | 2013-10-17 | 2013-10-21 | 18 | 0d |
| 20 |  | Exterior decoration | 10d | 2013-10-22 | 2013-11-04 | 19 | 0d |
| 21 |  | Waterproofing | 2d | 2013-11-05 | 2013-11-06 | 20 | 45d |
| 22 | 5 | **First Fix** | 8d | 2013-09-27 | 2013-10-08 | 17 | 25d |
| 23 |  | First fix carpentry | 8d | 2013-09-27 | 2013-10-08 | 11 | 25d |
| 24 |  | First fix plumbing | 6d | 2013-09-27 | 2013-10-04 | 9 | 27d |
| 25 |  | First fix electrics | 8d | 2013-09-27 | 2013-10-08 | 9 | 25d |
| 26 | 6 | **Fix** | 26d | 2013-11-05 | 2013-12-10 |  | 0d |
| 27 |  | Insulation | 6d | 2013-11-05 | 2013-11-12 | 20 | 0d |
| 28 |  | Plaster | 12d | 2013-11-13 | 2013-11-28 | 22, 27 | 0d |
| 29 |  | Floors | 8d | 2013-11-29 | 2013-12-10 | 28 | 0d |
| 30 | 7 | **Services** | 1d | 2013-12-11 | 2013-12-11 | 26 | 0d |
| 31 |  | Connect to services | 1d | 2013-12-11 | 2013-12-11 | 24, 25 | 0d |
| 32 | 8 | **Second Fix** | 9d | 2013-12-12 | 2013-12-24 | 30, 22 | 0d |
| 33 |  | Second fix carpentry | 7d | 2013-12-12 | 2013-12-20 |  | 2d |
| 34 |  | Second fix plumbing | 9d | 2013-12-12 | 2013-12-24 |  | 0d |
| 35 |  | Second fix electrics | 6d | 2013-12-12 | 2013-12-19 |  | 3d |
| 36 | 9 | **Finishing** | 17d | 2013-12-25 | 2014-01-16 | 32 | 0d |
| 37 |  | Decoration | 10d | 2013-12-25 | 2014-01-07 |  | 0d |
| 38 |  | Ceramic tiling | 6d | 2014-01-09 | 2014-01-16 | 37FS+1d | 0d |
| 39 | 10 | **Outside** | 6d | 2013-11-07 | 2013-11-14 | 15 | 45d |
| 40 |  | Landscaping | 6d | 2013-11-07 | 2013-11-14 |  | 45d |
| 41 |  | Driveway | 4d | 2013-11-07 | 2013-11-12 |  | 47d |
| 42 |  | Paths | 3d | 2013-11-07 | 2013-11-11 |  | 48d |
| 43 | 11 | **Completion** | 4d | 2014-01-17 | 2014-01-22 | 36, 39 | 0d |
| 44 |  | Final inspection | 2d | 2014-01-17 | 2014-01-20 | 21 | 0d |
| 45 |  | Correct snags | 2d | 2014-01-21 | 2014-01-22 | 44 | 0d |
| 46 |  | Signoff | 0d | 2014-01-22 | 2014-01-22 | 43 | 0d |

## Version 2 (saved 2013-05-31, file ssi-project2013advanced-example-02-house-a.mpp)

Last finish 2014-01-22 → 2014-02-05 (+14d).

Changed:

| ID | Task | Start | Finish |
| --- | --- | --- | --- |
| 1 | **Site** | 2013-05-30 → 2013-06-13 (+14d) | 2013-06-06 → 2013-06-20 (+14d) |
| 2 | Clear site | 2013-05-30 → 2013-06-13 (+14d) | 2013-06-04 → 2013-06-18 (+14d) |
| 3 | Set out | 2013-06-05 → 2013-06-19 (+14d) | 2013-06-06 → 2013-06-20 (+14d) |
| 4 | **Base** | 2013-06-07 → 2013-06-21 (+14d) | 2013-07-10 → 2013-07-24 (+14d) |
| 5 | Trenches | 2013-06-07 → 2013-06-21 (+14d) | 2013-06-11 → 2013-06-25 (+14d) |
| 6 | Footings | 2013-06-12 → 2013-06-26 (+14d) | 2013-06-18 → 2013-07-02 (+14d) |
| 7 | Concrete | 2013-06-19 → 2013-07-03 (+14d) | 2013-06-26 → 2013-07-10 (+14d) |
| 8 | Base brickwork | 2013-06-27 → 2013-07-11 (+14d) | 2013-07-04 → 2013-07-18 (+14d) |
| 9 | Plumbing and services | 2013-07-05 → 2013-07-19 (+14d) | 2013-07-10 → 2013-07-24 (+14d) |
| 10 | **Frame** | 2013-07-08 → 2013-07-22 (+14d) | 2013-09-10 → 2013-09-24 (+14d) |
| 11 | Floor | 2013-07-08 → 2013-07-22 (+14d) | 2013-07-19 → 2013-08-02 (+14d) |
| 12 | Frame | 2013-07-08 → 2013-07-22 (+14d) | 2013-08-12 → 2013-08-26 (+14d) |
| 13 | Structural steel | 2013-08-14 → 2013-08-28 (+14d) | 2013-08-27 → 2013-09-10 (+14d) |
| 14 | Trussing | 2013-08-28 → 2013-09-11 (+14d) | 2013-09-10 → 2013-09-24 (+14d) |
| 15 | **Lockup** | 2013-08-28 → 2013-09-11 (+14d) | 2013-11-06 → 2013-11-20 (+14d) |
| 16 | Window and door frames | 2013-08-28 → 2013-09-11 (+14d) | 2013-09-10 → 2013-09-24 (+14d) |
| 17 | Brickwork | 2013-09-16 → 2013-09-30 (+14d) | 2013-09-26 → 2013-10-10 (+14d) |
| 18 | Roof structure and tile | 2013-09-27 → 2013-10-11 (+14d) | 2013-10-16 → 2013-10-30 (+14d) |
| 19 | Fix rainwater goods | 2013-10-17 → 2013-10-31 (+14d) | 2013-10-21 → 2013-11-04 (+14d) |
| 20 | Exterior decoration | 2013-10-22 → 2013-11-05 (+14d) | 2013-11-04 → 2013-11-18 (+14d) |
| 21 | Waterproofing | 2013-11-05 → 2013-11-19 (+14d) | 2013-11-06 → 2013-11-20 (+14d) |
| 22 | **First Fix** | 2013-09-27 → 2013-10-11 (+14d) | 2013-10-08 → 2013-10-22 (+14d) |
| 23 | First fix carpentry | 2013-09-27 → 2013-10-11 (+14d) | 2013-10-08 → 2013-10-22 (+14d) |
| 24 | First fix plumbing | 2013-09-27 → 2013-10-11 (+14d) | 2013-10-04 → 2013-10-18 (+14d) |
| 25 | First fix electrics | 2013-09-27 → 2013-10-11 (+14d) | 2013-10-08 → 2013-10-22 (+14d) |
| 26 | **Fix** | 2013-11-05 → 2013-11-19 (+14d) | 2013-12-10 → 2013-12-24 (+14d) |
| 27 | Insulation | 2013-11-05 → 2013-11-19 (+14d) | 2013-11-12 → 2013-11-26 (+14d) |
| 28 | Plaster | 2013-11-13 → 2013-11-27 (+14d) | 2013-11-28 → 2013-12-12 (+14d) |
| 29 | Floors | 2013-11-29 → 2013-12-13 (+14d) | 2013-12-10 → 2013-12-24 (+14d) |
| 30 | **Services** | 2013-12-11 → 2013-12-25 (+14d) | 2013-12-11 → 2013-12-25 (+14d) |
| 31 | Connect to services | 2013-12-11 → 2013-12-25 (+14d) | 2013-12-11 → 2013-12-25 (+14d) |
| 32 | **Second Fix** | 2013-12-12 → 2013-12-26 (+14d) | 2013-12-24 → 2014-01-07 (+14d) |
| 33 | Second fix carpentry | 2013-12-12 → 2013-12-26 (+14d) | 2013-12-20 → 2014-01-03 (+14d) |
| 34 | Second fix plumbing | 2013-12-12 → 2013-12-26 (+14d) | 2013-12-24 → 2014-01-07 (+14d) |
| 35 | Second fix electrics | 2013-12-12 → 2013-12-26 (+14d) | 2013-12-19 → 2014-01-02 (+14d) |
| 36 | **Finishing** | 2013-12-25 → 2014-01-08 (+14d) | 2014-01-16 → 2014-01-30 (+14d) |
| 37 | Decoration | 2013-12-25 → 2014-01-08 (+14d) | 2014-01-07 → 2014-01-21 (+14d) |
| 38 | Ceramic tiling | 2014-01-09 → 2014-01-23 (+14d) | 2014-01-16 → 2014-01-30 (+14d) |
| 39 | **Outside** | 2013-11-07 → 2013-11-21 (+14d) | 2013-11-14 → 2013-11-28 (+14d) |
| 40 | Landscaping | 2013-11-07 → 2013-11-21 (+14d) | 2013-11-14 → 2013-11-28 (+14d) |
| 41 | Driveway | 2013-11-07 → 2013-11-21 (+14d) | 2013-11-12 → 2013-11-26 (+14d) |
| 42 | Paths | 2013-11-07 → 2013-11-21 (+14d) | 2013-11-11 → 2013-11-25 (+14d) |
| 43 | **Completion** | 2014-01-17 → 2014-01-31 (+14d) | 2014-01-22 → 2014-02-05 (+14d) |
| 44 | Final inspection | 2014-01-17 → 2014-01-31 (+14d) | 2014-01-20 → 2014-02-03 (+14d) |
| 45 | Correct snags | 2014-01-21 → 2014-02-04 (+14d) | 2014-01-22 → 2014-02-05 (+14d) |
| 46 | Signoff | 2014-01-22 → 2014-02-05 (+14d) | 2014-01-22 → 2014-02-05 (+14d) |

## Version 3 (saved 2013-06-10, file ssi-project2013advanced-example-04.mpp)

Last finish stays 2014-02-05.

Changed:

| ID | Task | Other |
| --- | --- | --- |
| 1 | **Site** | baseline start none → 2013-06-13; baseline finish none → 2013-06-20 |
| 2 | Clear site | resources none → Laborer 1; baseline start none → 2013-06-13; baseline finish none → 2013-06-18 |
| 3 | Set out | resources none → Laborer 1; baseline start none → 2013-06-19; baseline finish none → 2013-06-20 |
| 4 | **Base** | baseline start none → 2013-06-21; baseline finish none → 2013-07-24 |
| 5 | Trenches | resources none → Laborer 2; baseline start none → 2013-06-21; baseline finish none → 2013-06-25 |
| 6 | Footings | resources none → Laborer 2; baseline start none → 2013-06-26; baseline finish none → 2013-07-02 |
| 7 | Concrete | resources none → Laborer 1; baseline start none → 2013-07-03; baseline finish none → 2013-07-10 |
| 8 | Base brickwork | resources none → Laborer 1; baseline start none → 2013-07-11; baseline finish none → 2013-07-18 |
| 9 | Plumbing and services | resources none → Laborer 2; baseline start none → 2013-07-19; baseline finish none → 2013-07-24 |
| 10 | **Frame** | baseline start none → 2013-07-22; baseline finish none → 2013-09-24 |
| 11 | Floor | resources none → Laborer 1; baseline start none → 2013-07-22; baseline finish none → 2013-08-02 |
| 12 | Frame | resources none → Laborer 2; baseline start none → 2013-07-22; baseline finish none → 2013-08-26 |
| 13 | Structural steel | resources none → Laborer 1; baseline start none → 2013-08-28; baseline finish none → 2013-09-10 |
| 14 | Trussing | resources none → Laborer 2; baseline start none → 2013-09-11; baseline finish none → 2013-09-24 |
| 15 | **Lockup** | baseline start none → 2013-09-11; baseline finish none → 2013-11-20 |
| 16 | Window and door frames | resources none → Laborer 1; baseline start none → 2013-09-11; baseline finish none → 2013-09-24 |
| 17 | Brickwork | resources none → Laborer 1; baseline start none → 2013-09-30; baseline finish none → 2013-10-10 |
| 18 | Roof structure and tile | resources none → Ruth Tyler; baseline start none → 2013-10-11; baseline finish none → 2013-10-30 |
| 19 | Fix rainwater goods | resources none → Laborer 1; baseline start none → 2013-10-31; baseline finish none → 2013-11-04 |
| 20 | Exterior decoration | resources none → Laborer 2; baseline start none → 2013-11-05; baseline finish none → 2013-11-18 |
| 21 | Waterproofing | resources none → Laborer 1; baseline start none → 2013-11-19; baseline finish none → 2013-11-20 |
| 22 | **First Fix** | baseline start none → 2013-10-11; baseline finish none → 2013-10-22 |
| 23 | First fix carpentry | resources none → Carpenter 1; baseline start none → 2013-10-11; baseline finish none → 2013-10-22 |
| 24 | First fix plumbing | resources none → Gus Pipe; baseline start none → 2013-10-11; baseline finish none → 2013-10-18 |
| 25 | First fix electrics | resources none → Electrician 1; baseline start none → 2013-10-11; baseline finish none → 2013-10-22 |
| 26 | **Fix** | baseline start none → 2013-11-19; baseline finish none → 2013-12-24 |
| 27 | Insulation | resources none → Laborer 2; baseline start none → 2013-11-19; baseline finish none → 2013-11-26 |
| 28 | Plaster | resources none → Laborer 1; baseline start none → 2013-11-27; baseline finish none → 2013-12-12 |
| 29 | Floors | resources none → Laborer 2; baseline start none → 2013-12-13; baseline finish none → 2013-12-24 |
| 30 | **Services** | baseline start none → 2013-12-25; baseline finish none → 2013-12-25 |
| 31 | Connect to services | resources none → Laborer 1; baseline start none → 2013-12-25; baseline finish none → 2013-12-25 |
| 32 | **Second Fix** | baseline start none → 2013-12-26; baseline finish none → 2014-01-07 |
| 33 | Second fix carpentry | resources none → Hazel Wood; baseline start none → 2013-12-26; baseline finish none → 2014-01-03 |
| 34 | Second fix plumbing | resources none → Plumber 1; baseline start none → 2013-12-26; baseline finish none → 2014-01-07 |
| 35 | Second fix electrics | resources none → Lou Menns; baseline start none → 2013-12-26; baseline finish none → 2014-01-02 |
| 36 | **Finishing** | baseline start none → 2014-01-08; baseline finish none → 2014-01-30 |
| 37 | Decoration | resources none → Laborer 2; baseline start none → 2014-01-08; baseline finish none → 2014-01-21 |
| 38 | Ceramic tiling | resources none → Laborer 1; baseline start none → 2014-01-23; baseline finish none → 2014-01-30 |
| 39 | **Outside** | baseline start none → 2013-11-21; baseline finish none → 2013-11-28 |
| 40 | Landscaping | resources none → Laborer 1; baseline start none → 2013-11-21; baseline finish none → 2013-11-28 |
| 41 | Driveway | resources none → Laborer 2; baseline start none → 2013-11-21; baseline finish none → 2013-11-26 |
| 42 | Paths | resources none → Laborer 2; baseline start none → 2013-11-21; baseline finish none → 2013-11-25 |
| 43 | **Completion** | baseline start none → 2014-01-31; baseline finish none → 2014-02-05 |
| 44 | Final inspection | resources none → Inspector; baseline start none → 2014-01-31; baseline finish none → 2014-02-03 |
| 45 | Correct snags | resources none → Laborer 1; baseline start none → 2014-02-04; baseline finish none → 2014-02-05 |
| 46 | Signoff | resources none → Inspector; baseline start none → 2014-02-05; baseline finish none → 2014-02-05 |

## Version 4 (data date 2013-06-07, saved 2013-06-16, file ssi-project2013advanced-example-05.mpp)

Last finish 2014-02-05 → 2013-12-24 (-43d). Complete tasks 0 → 6.

Changed:

| ID | Task | Start | Finish | Complete | Total float |
| --- | --- | --- | --- | --- | --- |
| 1 | **Site** | 2013-06-13 → 2013-05-01 A (-43d) | 2013-06-20 → 2013-05-08 A (-43d) | 0% → 100% | 0d → none |
| 2 | Clear site | 2013-06-13 → 2013-05-01 A (-43d) | 2013-06-18 → 2013-05-06 A (-43d) | 0% → 100% | 0d → none |
| 3 | Set out | 2013-06-19 → 2013-05-07 A (-43d) | 2013-06-20 → 2013-05-08 A (-43d) | 0% → 100% | 0d → none |
| 4 | **Base** | 2013-06-21 → 2013-05-09 A (-43d) | 2013-07-24 → 2013-06-11 (-43d) | 0% → 88% | 0d → 81d |
| 5 | Trenches | 2013-06-21 → 2013-05-09 A (-43d) | 2013-06-25 → 2013-05-13 A (-43d) | 0% → 100% | 0d → none |
| 6 | Footings | 2013-06-26 → 2013-05-14 A (-43d) | 2013-07-02 → 2013-05-20 A (-43d) | 0% → 100% | 0d → none |
| 7 | Concrete | 2013-07-03 → 2013-05-21 A (-43d) | 2013-07-10 → 2013-05-28 A (-43d) | 0% → 100% | 0d → none |
| 8 | Base brickwork | 2013-07-11 → 2013-05-29 A (-43d) | 2013-07-18 → 2013-06-05 A (-43d) | 0% → 100% | 0d → none |
| 9 | Plumbing and services | 2013-07-19 → 2013-06-06 A (-43d) | 2013-07-24 → 2013-06-11 (-43d) | 0% → 25% |  |
| 10 | **Frame** | 2013-07-22 → 2013-06-07 A (-45d) | 2013-09-24 → 2013-08-12 (-43d) | 0% → 16% | 0d → 37d |
| 11 | Floor | 2013-07-22 → 2013-06-07 A (-45d) | 2013-08-02 → 2013-06-20 (-43d) | 0% → 25% |  |
| 12 | Frame | 2013-07-22 → 2013-06-07 A (-45d) | 2013-08-26 → 2013-07-12 (-45d) | 0% → 25% |  |
| 13 | Structural steel | 2013-08-28 → 2013-07-16 (-43d) | 2013-09-10 → 2013-07-29 (-43d) |  |  |
| 14 | Trussing | 2013-09-11 → 2013-07-30 (-43d) | 2013-09-24 → 2013-08-12 (-43d) |  |  |
| 15 | **Lockup** | 2013-09-11 → 2013-07-30 (-43d) | 2013-11-20 → 2013-10-08 (-43d) |  |  |
| 16 | Window and door frames | 2013-09-11 → 2013-07-30 (-43d) | 2013-09-24 → 2013-08-12 (-43d) |  |  |
| 17 | Brickwork | 2013-09-30 → 2013-08-16 (-45d) | 2013-10-10 → 2013-08-28 (-43d) |  |  |
| 18 | Roof structure and tile | 2013-10-11 → 2013-08-29 (-43d) | 2013-10-30 → 2013-09-17 (-43d) |  |  |
| 19 | Fix rainwater goods | 2013-10-31 → 2013-09-18 (-43d) | 2013-11-04 → 2013-09-20 (-45d) |  |  |
| 20 | Exterior decoration | 2013-11-05 → 2013-09-23 (-43d) | 2013-11-18 → 2013-10-04 (-45d) |  |  |
| 21 | Waterproofing | 2013-11-19 → 2013-10-07 (-43d) | 2013-11-20 → 2013-10-08 (-43d) |  |  |
| 22 | **First Fix** | 2013-10-11 → 2013-08-29 (-43d) | 2013-10-22 → 2013-09-09 (-43d) |  |  |
| 23 | First fix carpentry | 2013-10-11 → 2013-08-29 (-43d) | 2013-10-22 → 2013-09-09 (-43d) |  |  |
| 24 | First fix plumbing | 2013-10-11 → 2013-08-29 (-43d) | 2013-10-18 → 2013-09-05 (-43d) |  |  |
| 25 | First fix electrics | 2013-10-11 → 2013-08-29 (-43d) | 2013-10-22 → 2013-09-09 (-43d) |  |  |
| 26 | **Fix** | 2013-11-19 → 2013-10-07 (-43d) | 2013-12-24 → 2013-11-11 (-43d) |  |  |
| 27 | Insulation | 2013-11-19 → 2013-10-07 (-43d) | 2013-11-26 → 2013-10-14 (-43d) |  |  |
| 28 | Plaster | 2013-11-27 → 2013-10-15 (-43d) | 2013-12-12 → 2013-10-30 (-43d) |  |  |
| 29 | Floors | 2013-12-13 → 2013-10-31 (-43d) | 2013-12-24 → 2013-11-11 (-43d) |  |  |
| 30 | **Services** | 2013-12-25 → 2013-11-12 (-43d) | 2013-12-25 → 2013-11-12 (-43d) |  |  |
| 31 | Connect to services | 2013-12-25 → 2013-11-12 (-43d) | 2013-12-25 → 2013-11-12 (-43d) |  |  |
| 32 | **Second Fix** | 2013-12-26 → 2013-11-13 (-43d) | 2014-01-07 → 2013-11-25 (-43d) |  |  |
| 33 | Second fix carpentry | 2013-12-26 → 2013-11-13 (-43d) | 2014-01-03 → 2013-11-21 (-43d) |  |  |
| 34 | Second fix plumbing | 2013-12-26 → 2013-11-13 (-43d) | 2014-01-07 → 2013-11-25 (-43d) |  |  |
| 35 | Second fix electrics | 2013-12-26 → 2013-11-13 (-43d) | 2014-01-02 → 2013-11-20 (-43d) |  |  |
| 36 | **Finishing** | 2014-01-08 → 2013-11-26 (-43d) | 2014-01-30 → 2013-12-18 (-43d) |  |  |
| 37 | Decoration | 2014-01-08 → 2013-11-26 (-43d) | 2014-01-21 → 2013-12-09 (-43d) |  |  |
| 38 | Ceramic tiling | 2014-01-23 → 2013-12-11 (-43d) | 2014-01-30 → 2013-12-18 (-43d) |  |  |
| 39 | **Outside** | 2013-11-21 → 2013-10-09 (-43d) | 2013-11-28 → 2013-10-16 (-43d) |  |  |
| 40 | Landscaping | 2013-11-21 → 2013-10-09 (-43d) | 2013-11-28 → 2013-10-16 (-43d) |  |  |
| 41 | Driveway | 2013-11-21 → 2013-10-09 (-43d) | 2013-11-26 → 2013-10-14 (-43d) |  |  |
| 42 | Paths | 2013-11-21 → 2013-10-09 (-43d) | 2013-11-25 → 2013-10-11 (-45d) |  |  |
| 43 | **Completion** | 2014-01-31 → 2013-12-19 (-43d) | 2014-02-05 → 2013-12-24 (-43d) |  |  |
| 44 | Final inspection | 2014-01-31 → 2013-12-19 (-43d) | 2014-02-03 → 2013-12-20 (-45d) |  |  |
| 45 | Correct snags | 2014-02-04 → 2013-12-23 (-43d) | 2014-02-05 → 2013-12-24 (-43d) |  |  |
| 46 | Signoff | 2014-02-05 → 2013-12-24 (-43d) | 2014-02-05 → 2013-12-24 (-43d) |  |  |

## Version 5 (data date 2013-06-28, saved 2013-07-08, file ssi-project2013advanced-example-07.mpp)

Last finish 2013-12-24 → 2014-01-14 (+21d).

Changed:

| ID | Task | Start | Finish | Duration | Complete | Total float | Other |
| --- | --- | --- | --- | --- | --- | --- | --- |
| 1 | **Site** |  |  |  |  |  | baseline start 2013-06-13 → 2013-05-01; baseline finish 2013-06-20 → 2013-05-08 |
| 2 | Clear site |  |  |  |  |  | baseline start 2013-06-13 → 2013-05-01; baseline finish 2013-06-18 → 2013-05-06 |
| 3 | Set out |  |  |  |  |  | baseline start 2013-06-19 → 2013-05-07; baseline finish 2013-06-20 → 2013-05-08 |
| 4 | **Base** |  |  |  | 88% → 96% | 81d → 95.38d | baseline start 2013-06-21 → 2013-05-09; baseline finish 2013-07-24 → 2013-06-11 |
| 5 | Trenches |  |  |  |  |  | baseline start 2013-06-21 → 2013-05-09; baseline finish 2013-06-25 → 2013-05-13 |
| 6 | Footings |  |  |  |  |  | baseline start 2013-06-26 → 2013-05-14; baseline finish 2013-07-02 → 2013-05-20 |
| 7 | Concrete |  |  |  |  |  | baseline start 2013-07-03 → 2013-05-21; baseline finish 2013-07-10 → 2013-05-28 |
| 8 | Base brickwork |  |  |  |  |  | baseline start 2013-07-11 → 2013-05-29; baseline finish 2013-07-18 → 2013-06-05 |
| 9 | Plumbing and services |  |  |  | 25% → 75% | 81d → 95.38d | baseline start 2013-07-19 → 2013-06-06; baseline finish 2013-07-24 → 2013-06-11 |
| 10 | **Frame** |  | 2013-08-12 → 2013-08-21 (+9d) | 47d → 53.5d | 16% → 35% | 37d → 43.88d | baseline start 2013-07-22 → 2013-06-07; baseline finish 2013-09-24 → 2013-08-12 |
| 11 | Floor |  | 2013-06-20 → 2013-06-24 (+4d) | 10d → 11.25d | 25% → 75% | 74d → 86.12d | baseline start 2013-07-22 → 2013-06-07; baseline finish 2013-08-02 → 2013-06-20 |
| 12 | Frame |  | 2013-07-12 → 2013-07-16 (+4d) | 26d → 27.5d | 25% → 50% |  | baseline start 2013-07-22 → 2013-06-07; baseline finish 2013-08-26 → 2013-07-12 |
| 13 | Structural steel | 2013-07-16 → 2013-07-17 (+1d) | 2013-07-29 → 2013-08-02 (+4d) | 10d → 12.5d |  |  | baseline start 2013-08-28 → 2013-07-16; baseline finish 2013-09-10 → 2013-07-29 |
| 14 | Trussing | 2013-07-30 → 2013-08-05 (+6d) | 2013-08-12 → 2013-08-21 (+9d) | 10d → 12.5d |  | 12d → 14.12d | baseline start 2013-09-11 → 2013-07-30; baseline finish 2013-09-24 → 2013-08-12 |
| 15 | **Lockup** | 2013-07-30 → 2013-08-05 (+6d) | 2013-10-08 → 2013-10-29 (+21d) | 51d → 61.88d |  |  | baseline start 2013-09-11 → 2013-07-30; baseline finish 2013-11-20 → 2013-10-08 |
| 16 | Window and door frames | 2013-07-30 → 2013-08-05 (+6d) | 2013-08-12 → 2013-08-21 (+9d) | 10d → 12.38d |  |  | baseline start 2013-09-11 → 2013-07-30; baseline finish 2013-09-24 → 2013-08-12 |
| 17 | Brickwork | 2013-08-16 → 2013-08-26 (+10d) | 2013-08-28 → 2013-09-10 (+13d) | 9d → 11.25d |  |  | baseline start 2013-09-30 → 2013-08-16; baseline finish 2013-10-10 → 2013-08-28 |
| 18 | Roof structure and tile | 2013-08-29 → 2013-09-10 (+12d) | 2013-09-17 → 2013-10-03 (+16d) | 14d → 16.5d |  |  | baseline start 2013-10-11 → 2013-08-29; baseline finish 2013-10-30 → 2013-09-17 |
| 19 | Fix rainwater goods | 2013-09-18 → 2013-10-03 (+15d) | 2013-09-20 → 2013-10-08 (+18d) | 3d → 3.75d |  |  | baseline start 2013-10-31 → 2013-09-18; baseline finish 2013-11-04 → 2013-09-20 |
| 20 | Exterior decoration | 2013-09-23 → 2013-10-08 (+15d) | 2013-10-04 → 2013-10-25 (+21d) | 10d → 12.5d |  |  | baseline start 2013-11-05 → 2013-09-23; baseline finish 2013-11-18 → 2013-10-04 |
| 21 | Waterproofing | 2013-10-07 → 2013-10-25 (+18d) | 2013-10-08 → 2013-10-29 (+21d) | 2d → 2.5d |  | 45d → 44.5d | baseline start 2013-11-19 → 2013-10-07; baseline finish 2013-11-20 → 2013-10-08 |
| 22 | **First Fix** | 2013-08-29 → 2013-09-10 (+12d) | 2013-09-09 → 2013-09-23 (+14d) | 8d → 9d |  | 25d → 29.75d | baseline start 2013-10-11 → 2013-08-29; baseline finish 2013-10-22 → 2013-09-09 |
| 23 | First fix carpentry | 2013-08-29 → 2013-09-10 (+12d) | 2013-09-09 → 2013-09-23 (+14d) | 8d → 9d |  | 25d → 29.75d | baseline start 2013-10-11 → 2013-08-29; baseline finish 2013-10-22 → 2013-09-09 |
| 24 | First fix plumbing | 2013-08-29 → 2013-09-10 (+12d) | 2013-09-05 → 2013-09-19 (+14d) | 6d → 7d |  | 27d → 31.75d | baseline start 2013-10-11 → 2013-08-29; baseline finish 2013-10-18 → 2013-09-05 |
| 25 | First fix electrics | 2013-08-29 → 2013-09-10 (+12d) | 2013-09-09 → 2013-09-20 (+11d) |  |  | 25d → 30.75d | baseline start 2013-10-11 → 2013-08-29; baseline finish 2013-10-22 → 2013-09-09 |
| 26 | **Fix** | 2013-10-07 → 2013-10-25 (+18d) | 2013-11-11 → 2013-12-02 (+21d) |  |  |  | baseline start 2013-11-19 → 2013-10-07; baseline finish 2013-12-24 → 2013-11-11 |
| 27 | Insulation | 2013-10-07 → 2013-10-25 (+18d) | 2013-10-14 → 2013-11-04 (+21d) |  |  |  | baseline start 2013-11-19 → 2013-10-07; baseline finish 2013-11-26 → 2013-10-14 |
| 28 | Plaster | 2013-10-15 → 2013-11-04 (+20d) | 2013-10-30 → 2013-11-20 (+21d) |  |  |  | baseline start 2013-11-27 → 2013-10-15; baseline finish 2013-12-12 → 2013-10-30 |
| 29 | Floors | 2013-10-31 → 2013-11-20 (+20d) | 2013-11-11 → 2013-12-02 (+21d) |  |  |  | baseline start 2013-12-13 → 2013-10-31; baseline finish 2013-12-24 → 2013-11-11 |
| 30 | **Services** | 2013-11-12 → 2013-12-02 (+20d) | 2013-11-12 → 2013-12-03 (+21d) |  |  |  | baseline start 2013-12-25 → 2013-11-12; baseline finish 2013-12-25 → 2013-11-12 |
| 31 | Connect to services | 2013-11-12 → 2013-12-02 (+20d) | 2013-11-12 → 2013-12-03 (+21d) |  |  |  | baseline start 2013-12-25 → 2013-11-12; baseline finish 2013-12-25 → 2013-11-12 |
| 32 | **Second Fix** | 2013-11-13 → 2013-12-03 (+20d) | 2013-11-25 → 2013-12-16 (+21d) |  |  |  | baseline start 2013-12-26 → 2013-11-13; baseline finish 2014-01-07 → 2013-11-25 |
| 33 | Second fix carpentry | 2013-11-13 → 2013-12-03 (+20d) | 2013-11-21 → 2013-12-12 (+21d) |  |  |  | baseline start 2013-12-26 → 2013-11-13; baseline finish 2014-01-03 → 2013-11-21 |
| 34 | Second fix plumbing | 2013-11-13 → 2013-12-03 (+20d) | 2013-11-25 → 2013-12-16 (+21d) |  |  |  | baseline start 2013-12-26 → 2013-11-13; baseline finish 2014-01-07 → 2013-11-25 |
| 35 | Second fix electrics | 2013-11-13 → 2013-12-03 (+20d) | 2013-11-20 → 2013-12-11 (+21d) |  |  |  | baseline start 2013-12-26 → 2013-11-13; baseline finish 2014-01-02 → 2013-11-20 |
| 36 | **Finishing** | 2013-11-26 → 2013-12-16 (+20d) | 2013-12-18 → 2014-01-08 (+21d) |  |  |  | baseline start 2014-01-08 → 2013-11-26; baseline finish 2014-01-30 → 2013-12-18 |
| 37 | Decoration | 2013-11-26 → 2013-12-16 (+20d) | 2013-12-09 → 2013-12-30 (+21d) |  |  |  | baseline start 2014-01-08 → 2013-11-26; baseline finish 2014-01-21 → 2013-12-09 |
| 38 | Ceramic tiling | 2013-12-11 → 2013-12-31 (+20d) | 2013-12-18 → 2014-01-08 (+21d) |  |  |  | baseline start 2014-01-23 → 2013-12-11; baseline finish 2014-01-30 → 2013-12-18 |
| 39 | **Outside** | 2013-10-09 → 2013-10-29 (+20d) | 2013-10-16 → 2013-11-06 (+21d) |  |  | 45d → 44.5d | baseline start 2013-11-21 → 2013-10-09; baseline finish 2013-11-28 → 2013-10-16 |
| 40 | Landscaping | 2013-10-09 → 2013-10-29 (+20d) | 2013-10-16 → 2013-11-06 (+21d) |  |  | 45d → 44.5d | baseline start 2013-11-21 → 2013-10-09; baseline finish 2013-11-28 → 2013-10-16 |
| 41 | Driveway | 2013-10-09 → 2013-10-29 (+20d) | 2013-10-14 → 2013-11-04 (+21d) |  |  | 47d → 46.5d | baseline start 2013-11-21 → 2013-10-09; baseline finish 2013-11-26 → 2013-10-14 |
| 42 | Paths | 2013-10-09 → 2013-10-29 (+20d) | 2013-10-11 → 2013-11-01 (+21d) |  |  | 48d → 47.5d | baseline start 2013-11-21 → 2013-10-09; baseline finish 2013-11-25 → 2013-10-11 |
| 43 | **Completion** | 2013-12-19 → 2014-01-08 (+20d) | 2013-12-24 → 2014-01-14 (+21d) |  |  |  | baseline start 2014-01-31 → 2013-12-19; baseline finish 2014-02-05 → 2013-12-24 |
| 44 | Final inspection | 2013-12-19 → 2014-01-08 (+20d) | 2013-12-20 → 2014-01-10 (+21d) |  |  |  | baseline start 2014-01-31 → 2013-12-19; baseline finish 2014-02-03 → 2013-12-20 |
| 45 | Correct snags | 2013-12-23 → 2014-01-10 (+18d) | 2013-12-24 → 2014-01-14 (+21d) |  |  |  | baseline start 2014-02-04 → 2013-12-23; baseline finish 2014-02-05 → 2013-12-24 |
| 46 | Signoff | 2013-12-24 → 2014-01-14 (+21d) | 2013-12-24 → 2014-01-14 (+21d) |  |  |  | baseline start 2014-02-05 → 2013-12-24; baseline finish 2014-02-05 → 2013-12-24 |

## Version 6 (data date 2013-07-26, saved 2013-07-15, file ssi-project2013advanced-example-11.mpp)

Last finish 2014-01-14 → 2014-01-31 (+17d). Complete tasks 6 → 7.

Changed:

| ID | Task | Start | Finish | Duration | Complete | Total float | Predecessors | Other |
| --- | --- | --- | --- | --- | --- | --- | --- | --- |
| 4 | **Base** |  | 2013-06-11 → 2013-06-18 (+7d) | 24d → 28.62d | 96% → 83% | 95.38d → 103.88d |  |  |
| 8 | Base brickwork |  | 2013-06-05 A → 2013-06-17 (+12d) | 6d → 8d | 100% → 56% | none → 0d |  |  |
| 9 | Plumbing and services |  | 2013-06-11 → 2013-06-18 (+7d) |  |  | 95.38d → 103.88d |  | resources Laborer 2 → Plumber 1 |
| 10 | **Frame** |  | 2013-08-21 → 2013-08-28 (+7d) | 53.5d → 58.5d | 35% → 62% | 43.88d → 20d |  | baseline finish 2013-08-12 → 2013-08-21 |
| 11 | Floor |  | 2013-06-24 → 2013-06-26 A (+2d) |  | 75% → 100% | 86.12d → none |  | baseline finish 2013-06-20 → 2013-06-24 |
| 12 | Frame |  | 2013-07-16 A |  | 50% → 100% | 0d → none |  | resources Laborer 2 → Carpenter 1; baseline finish 2013-07-12 → 2013-07-16 |
| 13 | Structural steel | 2013-07-17 A | 2013-08-02 → 2013-08-07 (+5d) | 12.5d → 15d | 0% → 25% |  |  | baseline start 2013-07-16 → 2013-07-17; baseline finish 2013-07-29 → 2013-08-02 |
| 14 | Trussing | 2013-08-05 → 2013-08-07 (+2d) | 2013-08-21 → 2013-08-28 (+7d) | 12.5d → 15d |  | 14.12d → 20d |  | resources Laborer 2 → Ruth Tyler; baseline start 2013-07-30 → 2013-08-05; baseline finish 2013-08-12 → 2013-08-21 |
| 15 | **Lockup** | 2013-08-05 → 2013-08-07 (+2d) | 2013-10-29 → 2013-11-13 (+15d) | 61.88d → 70.5d |  |  |  | baseline start 2013-07-30 → 2013-08-05; baseline finish 2013-10-08 → 2013-10-29 |
| 16 | Window and door frames | 2013-08-05 → 2013-08-07 (+2d) | 2013-08-21 → 2013-09-02 (+12d) | 12.38d → 18d |  |  |  | resources Laborer 1 → Carpenter 1 [50%]; baseline start 2013-07-30 → 2013-08-05; baseline finish 2013-08-12 → 2013-08-21 |
| 17 | Brickwork | 2013-08-26 → 2013-09-05 (+10d) | 2013-09-10 → 2013-09-25 (+15d) | 11.25d → 14d |  |  |  | baseline start 2013-08-16 → 2013-08-26; baseline finish 2013-08-28 → 2013-09-10 |
| 18 | Roof structure and tile | 2013-09-10 → 2013-09-25 (+15d) | 2013-10-03 → 2013-10-18 (+15d) | 16.5d → 17d |  |  |  | baseline start 2013-08-29 → 2013-09-10; baseline finish 2013-09-17 → 2013-10-03 |
| 19 | Fix rainwater goods | 2013-10-03 → 2013-10-18 (+15d) | 2013-10-08 → 2013-10-24 (+16d) | 3.75d → 4d |  |  |  | baseline start 2013-09-18 → 2013-10-03; baseline finish 2013-09-20 → 2013-10-08 |
| 20 | Exterior decoration | 2013-10-08 → 2013-10-24 (+16d) | 2013-10-25 → 2013-11-11 (+17d) | 12.5d → 12d |  |  |  | baseline start 2013-09-23 → 2013-10-08; baseline finish 2013-10-04 → 2013-10-25 |
| 21 | Waterproofing | 2013-10-25 → 2013-11-11 (+17d) | 2013-10-29 → 2013-11-13 (+15d) |  |  | 44.5d → 24.12d |  | resources Laborer 1 → Laborer 2; baseline start 2013-10-07 → 2013-10-25; baseline finish 2013-10-08 → 2013-10-29 |
| 22 | **First Fix** | 2013-09-10 → 2013-09-25 (+15d) | 2013-09-23 → 2013-10-09 (+16d) | 9d → 10d |  | 29.75d → 31d |  | baseline start 2013-08-29 → 2013-09-10; baseline finish 2013-09-09 → 2013-09-23 |
| 23 | First fix carpentry | 2013-09-10 → 2013-09-25 (+15d) | 2013-09-23 → 2013-10-09 (+16d) | 9d → 10d |  | 29.75d → 31d |  | baseline start 2013-08-29 → 2013-09-10; baseline finish 2013-09-09 → 2013-09-23 |
| 24 | First fix plumbing | 2013-09-10 → 2013-09-25 (+15d) | 2013-09-19 → 2013-10-07 (+18d) | 7d → 8d |  | 31.75d → 33d |  | baseline start 2013-08-29 → 2013-09-10; baseline finish 2013-09-05 → 2013-09-19 |
| 25 | First fix electrics | 2013-09-10 → 2013-09-25 (+15d) | 2013-09-20 → 2013-10-07 (+17d) |  |  | 30.75d → 33d |  | baseline start 2013-08-29 → 2013-09-10; baseline finish 2013-09-09 → 2013-09-20 |
| 26 | **Fix** | 2013-10-25 → 2013-11-11 (+17d) | 2013-12-02 → 2013-12-19 (+17d) | 26d → 28d |  |  |  | baseline start 2013-10-07 → 2013-10-25; baseline finish 2013-11-11 → 2013-12-02 |
| 27 | Insulation | 2013-10-25 → 2013-11-11 (+17d) | 2013-11-04 → 2013-11-21 (+17d) | 6d → 8d |  |  |  | resources Laborer 2 → Laborer 1; baseline start 2013-10-07 → 2013-10-25; baseline finish 2013-10-14 → 2013-11-04 |
| 28 | Plaster | 2013-11-04 → 2013-11-21 (+17d) | 2013-11-20 → 2013-12-09 (+19d) |  |  |  |  | resources Laborer 1 → Master Builder; baseline start 2013-10-15 → 2013-11-04; baseline finish 2013-10-30 → 2013-11-20 |
| 29 | Floors | 2013-11-20 → 2013-12-09 (+19d) | 2013-12-02 → 2013-12-19 (+17d) |  |  |  |  | baseline start 2013-10-31 → 2013-11-20; baseline finish 2013-11-11 → 2013-12-02 |
| 30 | **Services** | 2013-12-02 → 2013-12-19 (+17d) | 2013-12-03 → 2013-12-20 (+17d) |  |  |  |  | baseline start 2013-11-12 → 2013-12-02; baseline finish 2013-11-12 → 2013-12-03 |
| 31 | Connect to services | 2013-12-02 → 2013-12-19 (+17d) | 2013-12-03 → 2013-12-20 (+17d) |  |  |  |  | baseline start 2013-11-12 → 2013-12-02; baseline finish 2013-11-12 → 2013-12-03 |
| 32 | **Second Fix** | 2013-12-03 → 2013-12-20 (+17d) | 2013-12-16 → 2014-01-03 (+18d) | 9d → 10d |  |  |  | baseline start 2013-11-13 → 2013-12-03; baseline finish 2013-11-25 → 2013-12-16 |
| 33 | Second fix carpentry | 2013-12-03 → 2013-12-20 (+17d) | 2013-12-12 → 2013-12-31 (+19d) |  |  | 2d → 3d |  | baseline start 2013-11-13 → 2013-12-03; baseline finish 2013-11-21 → 2013-12-12 |
| 34 | Second fix plumbing | 2013-12-03 → 2013-12-20 (+17d) | 2013-12-16 → 2014-01-02 (+17d) |  |  | 0d → 1d |  | baseline start 2013-11-13 → 2013-12-03; baseline finish 2013-11-25 → 2013-12-16 |
| 35 | Second fix electrics | 2013-12-03 → 2013-12-20 (+17d) | 2013-12-11 → 2014-01-03 (+23d) | 6d → 10d |  | 3d → 0d |  | resources Lou Menns → Lou Menns [66.7%]; baseline start 2013-11-13 → 2013-12-03; baseline finish 2013-11-20 → 2013-12-11 |
| 36 | **Finishing** | 2013-12-16 → 2014-01-03 (+18d) | 2014-01-08 → 2014-01-27 (+19d) | 17d → 16d |  |  |  | baseline start 2013-11-26 → 2013-12-16; baseline finish 2013-12-18 → 2014-01-08 |
| 37 | Decoration | 2013-12-16 → 2014-01-03 (+18d) | 2013-12-30 → 2014-01-16 (+17d) | 10d → 9d |  |  |  | baseline start 2013-11-26 → 2013-12-16; baseline finish 2013-12-09 → 2013-12-30 |
| 38 | Ceramic tiling | 2013-12-31 → 2014-01-17 (+17d) | 2014-01-08 → 2014-01-27 (+19d) |  |  |  |  | baseline start 2013-12-11 → 2013-12-31; baseline finish 2013-12-18 → 2014-01-08 |
| 39 | **Outside** | 2013-10-29 → 2013-11-14 (+16d) | 2013-11-06 → 2013-12-24 (+48d) | 6d → 28.5d |  | 44.5d → 24d |  | baseline start 2013-10-09 → 2013-11-04; baseline finish 2013-10-16 → 2013-12-05 |
| 40 | Landscaping | 2013-10-29 → 2013-11-14 (+16d) | 2013-11-06 → 2013-11-29 (+23d) |  |  | 44.5d → 24.12d |  | baseline start 2013-10-09 → 2013-11-04; baseline finish 2013-10-16 → 2013-11-12 |
| 41 | Driveway | 2013-10-29 → 2013-11-29 (+31d) | 2013-11-04 → 2013-12-05 (+31d) |  |  | 46.5d → 37.25d | none → 40 | baseline start 2013-10-09 → 2013-11-12; baseline finish 2013-10-14 → 2013-11-18 |
| 42 | Paths | 2013-10-29 → 2013-12-19 (+51d) | 2013-11-01 → 2013-12-24 (+53d) |  |  | 47.5d → 24d | none → 40 | baseline start 2013-10-09 → 2013-12-02; baseline finish 2013-10-11 → 2013-12-05 |
| 43 | **Completion** | 2014-01-08 → 2014-01-27 (+19d) | 2014-01-14 → 2014-01-31 (+17d) |  |  |  |  | baseline start 2013-12-19 → 2014-01-08; baseline finish 2013-12-24 → 2014-01-14 |
| 44 | Final inspection | 2014-01-08 → 2014-01-27 (+19d) | 2014-01-10 → 2014-01-29 (+19d) |  |  |  |  | baseline start 2013-12-19 → 2014-01-08; baseline finish 2013-12-20 → 2014-01-10 |
| 45 | Correct snags | 2014-01-10 → 2014-01-29 (+19d) | 2014-01-14 → 2014-01-31 (+17d) |  |  |  |  | baseline start 2013-12-23 → 2014-01-10; baseline finish 2013-12-24 → 2014-01-14 |
| 46 | Signoff | 2014-01-14 → 2014-01-31 (+17d) | 2014-01-14 → 2014-01-31 (+17d) |  |  |  |  | baseline start 2013-12-24 → 2014-01-14; baseline finish 2013-12-24 → 2014-01-14 |

## Version 7 (data date 2013-08-30, saved 2013-07-15, file ssi-project2013advanced-example-13.mpp)

Last finish 2014-01-31 → 2014-02-05 (+5d).

Changed:

| ID | Task | Start | Finish | Duration | Complete | Total float |
| --- | --- | --- | --- | --- | --- | --- |
| 10 | **Frame** |  | 2013-08-28 → 2013-08-29 (+1d) | 58.5d → 59.75d | 62% → 69% | 20d → 21.95d |
| 13 | Structural steel |  | 2013-08-07 → 2013-08-09 (+2d) | 15d → 17.5d | 25% → 43% |  |
| 14 | Trussing | 2013-08-07 A | 2013-08-28 → 2013-08-29 (+1d) | 15d → 16.25d | 0% → 23% | 20d → 21.95d |
| 15 | **Lockup** | 2013-08-07 A | 2013-11-13 → 2013-11-18 (+5d) | 70.5d → 73.2d | 0% → 3% | 0d → 24.05d |
| 16 | Window and door frames | 2013-08-07 A | 2013-09-02 → 2013-09-04 (+2d) | 18d → 19.75d | 0% → 9% |  |
| 17 | Brickwork | 2013-09-05 → 2013-09-09 (+4d) | 2013-09-25 → 2013-09-30 (+5d) | 14d → 14.75d |  |  |
| 18 | Roof structure and tile | 2013-09-25 → 2013-09-30 (+5d) | 2013-10-18 → 2013-10-23 (+5d) |  |  |  |
| 19 | Fix rainwater goods | 2013-10-18 → 2013-10-23 (+5d) | 2013-10-24 → 2013-10-29 (+5d) | 4d → 4.25d |  |  |
| 20 | Exterior decoration | 2013-10-24 → 2013-10-29 (+5d) | 2013-11-11 → 2013-11-14 (+3d) | 12d → 11.25d |  |  |
| 21 | Waterproofing | 2013-11-11 → 2013-11-14 (+3d) | 2013-11-13 → 2013-11-18 (+5d) |  |  | 24.12d → 24.05d |
| 22 | **First Fix** | 2013-09-25 → 2013-09-30 (+5d) | 2013-10-09 → 2013-10-14 (+5d) |  |  | 31d → 30.5d |
| 23 | First fix carpentry | 2013-09-25 → 2013-09-30 (+5d) | 2013-10-09 → 2013-10-14 (+5d) |  |  | 31d → 30.5d |
| 24 | First fix plumbing | 2013-09-25 → 2013-09-30 (+5d) | 2013-10-07 → 2013-10-10 (+3d) |  |  | 33d → 32.5d |
| 25 | First fix electrics | 2013-09-25 → 2013-09-30 (+5d) | 2013-10-07 → 2013-10-10 (+3d) |  |  | 33d → 32.5d |
| 26 | **Fix** | 2013-11-11 → 2013-11-14 (+3d) | 2013-12-19 → 2013-12-24 (+5d) |  |  |  |
| 27 | Insulation | 2013-11-11 → 2013-11-14 (+3d) | 2013-11-21 → 2013-11-26 (+5d) |  |  |  |
| 28 | Plaster | 2013-11-21 → 2013-11-26 (+5d) | 2013-12-09 → 2013-12-12 (+3d) |  |  |  |
| 29 | Floors | 2013-12-09 → 2013-12-12 (+3d) | 2013-12-19 → 2013-12-24 (+5d) |  |  |  |
| 30 | **Services** | 2013-12-19 → 2013-12-24 (+5d) | 2013-12-20 → 2013-12-25 (+5d) |  |  |  |
| 31 | Connect to services | 2013-12-19 → 2013-12-24 (+5d) | 2013-12-20 → 2013-12-25 (+5d) |  |  |  |
| 32 | **Second Fix** | 2013-12-20 → 2013-12-25 (+5d) | 2014-01-03 → 2014-01-08 (+5d) |  |  |  |
| 33 | Second fix carpentry | 2013-12-20 → 2013-12-25 (+5d) | 2013-12-31 → 2014-01-03 (+3d) |  |  |  |
| 34 | Second fix plumbing | 2013-12-20 → 2013-12-25 (+5d) | 2014-01-02 → 2014-01-07 (+5d) |  |  |  |
| 35 | Second fix electrics | 2013-12-20 → 2013-12-25 (+5d) | 2014-01-03 → 2014-01-08 (+5d) |  |  |  |
| 36 | **Finishing** | 2014-01-03 → 2014-01-08 (+5d) | 2014-01-27 → 2014-01-30 (+3d) |  |  |  |
| 37 | Decoration | 2014-01-03 → 2014-01-08 (+5d) | 2014-01-16 → 2014-01-21 (+5d) |  |  |  |
| 38 | Ceramic tiling | 2014-01-17 → 2014-01-22 (+5d) | 2014-01-27 → 2014-01-30 (+3d) |  |  |  |
| 39 | **Outside** | 2013-11-14 → 2013-11-18 (+4d) | 2013-12-24 → 2013-12-26 (+2d) | 28.5d → 28.3d |  | 24d → 24.05d |
| 40 | Landscaping | 2013-11-14 → 2013-11-18 (+4d) | 2013-11-29 → 2013-12-03 (+4d) |  |  | 24.12d → 24.05d |
| 41 | Driveway | 2013-11-29 → 2013-12-03 (+4d) | 2013-12-05 → 2013-12-09 (+4d) |  |  |  |
| 42 | Paths | 2013-12-19 → 2013-12-24 (+5d) | 2013-12-24 → 2013-12-26 (+2d) |  |  | 24d → 24.2d |
| 43 | **Completion** | 2014-01-27 → 2014-01-30 (+3d) | 2014-01-31 → 2014-02-05 (+5d) |  |  |  |
| 44 | Final inspection | 2014-01-27 → 2014-01-30 (+3d) | 2014-01-29 → 2014-02-03 (+5d) |  |  |  |
| 45 | Correct snags | 2014-01-29 → 2014-02-03 (+5d) | 2014-01-31 → 2014-02-05 (+5d) |  |  |  |
| 46 | Signoff | 2014-01-31 → 2014-02-05 (+5d) | 2014-01-31 → 2014-02-05 (+5d) |  |  |  |
